# InstallProjectServer2013

Schedule from MS Project, 2015-12-27 to 2016-01-25.

## Calendars

- Standard: Mon-Thu 08:00-12:00, 13:00-17:00; Fri off; Sat-Sun 08:00-12:00, 13:00-17:00.

## Resources

| Resource |
| --- |
| مدير المشروع |
| مبرمج الموقع |
| برمجية Project 2013 |

## Schedule

| ID | WBS | Task | Duration | Start | Finish | Predecessors | Total slack | Constraint |
| --- | --- | --- | --- | --- | --- | --- | --- | --- |
| 1 | 1 | خطة نشر Project Server 2013 | 1d? | 2015-12-27 | 2015-12-27 |  | 0d |  |
| 2 | 2 | **التحضير للنشر** | 3d? | 2015-12-28 | 2015-12-30 | 1 | 0d |  |
| 3 | 2.1 | إنشاء مستخدمين ومجموعات في خدمة Active Directory | 1d? | 2015-12-28 | 2015-12-28 |  | 0d |  |
| 4 | 2.2 | **تكوين خادم SQL وAnalysis Services** | 2d? | 2015-12-29 | 2015-12-30 | 3 | 0d |  |
| 5 | 2.2.1 | تكوين إعدادات شبكة خادم SQL | 1d? | 2015-12-29 | 2015-12-29 |  | 0d |  |
| 6 | 2.2.2 | تكوين Analysis Services لإنشاء مكعبات Project Server OLAP | 1d? | 2015-12-30 | 2015-12-30 | 5 | 0d | finish no earlier than 2015-12-30 |
| 7 | 2.2.3 | إنشاء ملفات TempDB إضافية | 1d? | 2015-12-29 | 2015-12-29 |  | 1d |  |
| 8 | 3 | **تثبيت SharePoint Server 2013** | 5d? | 2015-12-31 | 2016-01-05 | 2 | 0d |  |
| 9 | 3.1 | تجهيز خوادم المزرعة | 1d? | 2015-12-31 | 2015-12-31 |  | 0d |  |
| 10 | 3.2 | تثبيت SharePoint 2013 على خوادم المزرعة | 1d? | 2016-01-02 | 2016-01-02 | 9 | 0d |  |
| 11 | 3.3 | إنشاء المزرعة وتكوينها | 1d? | 2016-01-03 | 2016-01-03 | 10 | 0d |  |
| 12 | 3.4 | إضافة خوادم ويب إلى المزرعة | 1d? | 2016-01-04 | 2016-01-04 | 11 | 0d |  |
| 13 | 3.5 | تنفيذ المهام الإدارية | 1d? | 2016-01-05 | 2016-01-05 | 12 | 0d |  |
| 14 | 4 | **تثبيت Project Server 2013 وتكوينه** | 5d? | 2016-01-06 | 2016-01-11 | 2, 8 | 0d |  |
| 15 | 4.1 | تثبيت Project Server 2013 | 1d? | 2016-01-06 | 2016-01-06 |  | 0d |  |
| 16 | 4.2 | تشغيل معالج تكوين منتجات SharePoint وتقنياته | 1d? | 2016-01-07 | 2016-01-07 | 15 | 0d |  |
| 17 | 4.3 | **تكوين الخدمات** | 3d? | 2016-01-09 | 2016-01-11 |  | 0d |  |
| 18 | 4.3.1 | بدء تشغيل خدمة تطبيق Project Server | 1d? | 2016-01-09 | 2016-01-09 | 16 | 0d |  |
| 19 | 4.3.2 | تسجيل حساب مُدار | 1d? | 2016-01-10 | 2016-01-10 | 18 | 0d |  |
| 20 | 4.3.3 | إنشاء تطبيق خدمة Project Server | 1d? | 2016-01-11 | 2016-01-11 | 19 | 0d |  |
| 21 | 5 | **إنشاء موقع Project Web App** | 5d? | 2016-01-12 | 2016-01-17 | 14 | 0d |  |
| 22 | 5.1 | **نشر Project Web App مع مجموعة مواقع مشتركة جديدة** | 2d? | 2016-01-12 | 2016-01-13 |  | 0d |  |
| 23 | 5.1.1 | إنشاء موقع ويب ذي مستوى أعلى | 1d? | 2016-01-12 | 2016-01-12 |  | 0d |  |
| 24 | 5.1.2 | إنشاء موقع Project Web App | 1d? | 2016-01-13 | 2016-01-13 | 23 | 0d |  |

Notes:
- 1: http://go.microsoft.com/fwlink/p/?LinkID=257341
- 2: http://go.microsoft.com/fwlink/p/?LinkId=257342
- 4: http://go.microsoft.com/fwlink/p/?LinkId=257344
- 8: http://go.microsoft.com/fwlink/p/?LinkId=257345
- 13: قم بتكوين ما يلي: / · تجميع بيانات الاستخدام والحماية / · التسجيل التشخيصي / · البريد الإلكتروني الوارد / · البريد الإلكتروني الصادر / ·
- 14: http://go.microsoft.com/fwlink/p/?LinkId=257346
- 21: http://go.microsoft.com/fwlink/p/?LinkId=257349
- 22: http://go.microsoft.com/fwlink/p/?LinkId=257350

| ID | WBS | Task | Duration | Start | Finish | Predecessors | Total slack | Constraint |
| --- | --- | --- | --- | --- | --- | --- | --- | --- |
| 25 | 5.2 | **نشر Project Web App في مجموعة مواقع مشتركة موجودة** | 3d? | 2016-01-14 | 2016-01-17 | 22 | 0d |  |
| 26 | 5.2.1 | **تمكين ميزات مجموعة المواقع المشتركة الخاصة بـ Project Web App** | 2d? | 2016-01-14 | 2016-01-16 |  | 0d |  |
| 27 | 5.2.1.1 | إنشاء قاعدة بيانات Project Web App | 1d? | 2016-01-14 | 2016-01-14 |  | 0d | start no earlier than 2016-01-14 |
| 28 | 5.2.1.2 | تمكين ميزات مجموعة المواقع المشتركة الخاصة بـ Project Web App | 1d? | 2016-01-16 | 2016-01-16 | 27 | 0d |  |
| 29 | 5.2.2 | إنشاء موقع Project Web App في مجموعة مواقع مشتركة موجودة | 1d? | 2016-01-17 | 2016-01-17 | 26 | 0d |  |
| 30 | 6 | **تكوين إعداد التقارير لـ Project Web App** | 7d? | 2016-01-18 | 2016-01-25 | 21 | 0d |  |
| 31 | 6.1 | تكوين المتطلبات الأساسية | 1d? | 2016-01-18 | 2016-01-18 |  | 0d |  |
| 32 | 6.2 | الحسابات ومجموعات الأمان | 1d? | 2016-01-19 | 2016-01-19 | 31 | 0d |  |
| 33 | 6.3 | إضافة تسجيل دخول لمجموعة كتاب التقرير | 1d? | 2016-01-20 | 2016-01-20 | 32 | 0d |  |
| 34 | 6.4 | تثبيت كائنات إدارة تحليل SQL Server 2008 | 1d? | 2016-01-21 | 2016-01-21 | 33 | 0d |  |
| 35 | 6.5 | تكوين إعدادات Excel Services | 1d? | 2016-01-23 | 2016-01-23 | 34 | 0d |  |
| 36 | 6.6 | تكوين إعدادات "خدمة التخزين الآمن" | 1d? | 2016-01-24 | 2016-01-24 | 35 | 0d |  |
| 37 | 6.7 | تعبئة مجموعات "Active Directory لكتاب التقارير ومشاهدي التقارير" | 1d? | 2016-01-25 | 2016-01-25 | 36 | 0d |  |

Notes:
- 25: http://go.microsoft.com/fwlink/p/?LinkId=257352
- 26: http://go.microsoft.com/fwlink/p/?LinkId=257353
- 29: http://go.microsoft.com/fwlink/p/?LinkId=257354
- 30: http://go.microsoft.com/fwlink/p/?LinkId=257355
