# تجهيز التقرير السنوي

Schedule from MS Project, 2015-12-07 to 2016-01-25, A marks actual dates.
يخاطب هذا القالب من وجهة نظر "مالية وحسابية" الأنشطة العامة التي تحدد جهداً مثالياً لإعداد "تقرير مالي سنوي". يتضمن القالب الأنشطة التي يتم التركيز عليها للحصول على المعلومات الضرورية من أقسام متنوعة للعمل مع أقسام أخرى (على سبيل المثال، العلاقات العامة والشئون القانونية) لضمان أن يتم تقديم كافة المعلومات المطلوبة بدقة وصولاً إلى عملية الطباعة والتوزيع.

## Calendars

- قياسي: Mon-Thu 08:00-12:00, 13:00-17:00; Fri off; Sat-Sun 08:00-12:00, 13:00-17:00.

## Resources

| Resource |
| --- |
| لجنة مراجعة الحسابات |
| إدارة الشؤون القانونية |
| المراجعون الخارجيون |
| اللجنة التنفيذية |
| رئيس الشؤون المالية/المراقب |
| مجموعة التسويق |
| لجنة التخطيط الاستراتيجي |
| إدارة العلاقات العامة/علاقات المستثمرين |
| رئيس مجلس الإدارة |

## Schedule

| ID | WBS | Task | Type | Duration | Start | Finish | Predecessors | Complete | Baseline start | Baseline finish | Baseline duration | Total slack | Free slack | Resources | Work | Actual work |
| --- | --- | --- | --- | --- | --- | --- | --- | --- | --- | --- | --- | --- | --- | --- | --- | --- |
| 1 | 1 | **تنفيذ التخطيط الأولي** |  | 6d? | 2015-12-07 A | 2015-12-13 A |  | 100% | 2015-12-07 | 2015-12-13 | 6d? |  |  |  | 48h | 48h |
| 2 | 1.1 | مراجعة ملف المشروع/الدروس المستفادة من عملية إعداد التقرير السنوي للسنة الماضية |  | 1d? | 2015-12-07 A | 2015-12-07 A |  | 100% | 2015-12-07 | 2015-12-07 | 1d? |  |  | لجنة التخطيط الاستراتيجي | 8h | 8h |
| 3 | 1.2 | تأكيد أية تغييرات تتعلق بمتطلبات إصدار التقارير المالية |  | 1d? | 2015-12-08 A | 2015-12-08 A | 2 | 100% | 2015-12-08 | 2015-12-08 | 1d? |  |  | رئيس الشؤون المالية/المراقب | 8h | 8h |
| 4 | 1.3 | تحديد موضوع التقرير السنوي ومتطلبات المقاطع |  | 1d? | 2015-12-09 A | 2015-12-09 A | 3 | 100% | 2015-12-09 | 2015-12-09 | 1d? |  |  | لجنة التخطيط الاستراتيجي | 8h | 8h |
| 5 | 1.4 | تأكيد إضافة المقاطع الأخرى أو إزالتها |  | 1d? | 2015-12-10 A | 2015-12-10 A | 4 | 100% | 2015-12-10 | 2015-12-10 | 1d? |  |  | لجنة التخطيط الاستراتيجي | 8h | 8h |
| 6 | 1.5 | تأكيد حفظ ملفات 'لجنة مراقبة عمليات البورصة' (SEC) والنقاط المطلوب التحقق منها في التقرير السنوي |  | 1d? | 2015-12-12 A | 2015-12-12 A | 5 | 100% | 2015-12-12 | 2015-12-12 | 1d? |  |  | رئيس الشؤون المالية/المراقب | 8h | 8h |
| 7 | 1.6 | اختيار مراجعي الحسابات الداخليين |  | 1d? | 2015-12-13 A | 2015-12-13 A | 6 | 100% | 2015-12-13 | 2015-12-13 | 1d? |  |  | لجنة مراجعة الحسابات | 8h | 8h |
| 8 | 1.7 | اكتمال التخطيط الأولي | milestone | 0d | 2015-12-13 A | 2015-12-13 A | 7 | 100% | 2015-12-13 | 2015-12-13 | 0d |  |  |  |  |  |
| 9 | 2 | **تصميم التقرير السنوي** |  | 6d? | 2015-12-14 A | 2015-12-20 A |  | 100% | 2015-12-14 | 2015-12-20 | 6d? |  |  |  | 48h | 48h |
| 10 | 2.1 | تعيين موارد للتصميم الأولي |  | 1d? | 2015-12-14 A | 2015-12-14 A | 8 | 100% | 2015-12-14 | 2015-12-14 | 1d? |  |  | لجنة التخطيط الاستراتيجي | 8h | 8h |
| 11 | 2.2 | إعداد التصميم الأولي ومتطلبات المعلومات |  | 1d? | 2015-12-15 A | 2015-12-15 A | 10 | 100% | 2015-12-15 | 2015-12-15 | 1d? |  |  | لجنة التخطيط الاستراتيجي | 8h | 8h |
| 12 | 2.3 | **تقييم/تأكيد آليات توزيع التقارير** |  | 3d? | 2015-12-16 A | 2015-12-19 A |  | 100% | 2015-12-16 | 2015-12-19 | 3d? |  |  |  | 24h | 24h |
| 13 | 2.3.1 | تقييم/تأكيد تصميم التقرير السنوي ومورّدي الاتصالات |  | 1d? | 2015-12-16 A | 2015-12-16 A | 11 | 100% | 2015-12-16 | 2015-12-16 | 1d? |  |  | إدارة العلاقات العامة/علاقات المستثمرين | 8h | 8h |
| 14 | 2.3.2 | تقييم/تأكيد تصميم موقع ويب للشركة ومتطلبات التكامل |  | 1d? | 2015-12-17 A | 2015-12-17 A | 13 | 100% | 2015-12-17 | 2015-12-17 | 1d? |  |  | إدارة العلاقات العامة/علاقات المستثمرين | 8h | 8h |
| 15 | 2.3.3 | تقييم/تأكيد عملية إصدار التقرير السنوي ومورّدي البريد |  | 1d? | 2015-12-19 A | 2015-12-19 A | 14 | 100% | 2015-12-19 | 2015-12-19 | 1d? |  |  | إدارة العلاقات العامة/علاقات المستثمرين | 8h | 8h |
| 16 | 2.3.4 | تأكيد آليات توزيع التقرير | milestone | 0d | 2015-12-19 A | 2015-12-19 A | 15 | 100% | 2015-12-19 | 2015-12-19 | 0d |  |  | إدارة العلاقات العامة/علاقات المستثمرين |  |  |
| 17 | 2.4 | تخطيط/تأكيد جدول الإصدار |  | 1d? | 2015-12-20 A | 2015-12-20 A | 16 | 100% | 2015-12-20 | 2015-12-20 | 1d? |  |  | إدارة العلاقات العامة/علاقات المستثمرين | 8h | 8h |
| 18 | 2.5 | اكتمال تصميم التقرير السنوي | milestone | 0d | 2015-12-20 A | 2015-12-20 A | 17 | 100% | 2015-12-20 | 2015-12-20 | 0d |  |  |  |  |  |
| 19 | 3 | **إعداد نموذج ‎10-K للجنة مراقبة عمليات البورصة (SEC) وجداول عمليات إصدار وثائق الوكيل** |  | 3d? | 2015-12-21 A | 2015-12-23 A |  | 100% | 2015-12-21 | 2015-12-23 | 3d? |  |  |  | 24h | 24h |
| 20 | 3.1 | تخطيط/تأكيد جدول إصدار ‎10-K |  | 1d? | 2015-12-21 A | 2015-12-21 A | 18 | 100% | 2015-12-21 | 2015-12-21 | 1d? |  |  | رئيس الشؤون المالية/المراقب | 8h | 8h |
| 21 | 3.2 | تخطيط/تأكيد جدول إصدار 'تقرير الوكيل' |  | 1d? | 2015-12-22 A | 2015-12-22 A | 20 | 100% | 2015-12-22 | 2015-12-22 | 1d? |  |  | رئيس الشؤون المالية/المراقب | 8h | 8h |
| 22 | 3.3 | تحديد خطوات العملية اللازمة لتحقيق جدول الإصدار |  | 1d? | 2015-12-23 A | 2015-12-23 A | 21 | 100% | 2015-12-23 | 2015-12-23 | 1d? |  |  | رئيس الشؤون المالية/المراقب | 8h | 8h |
| 23 | 3.4 | اكتمال نموذج ‎10-K للجنة مراقبة عمليات البورصة (SEC) وجداول عمليات إصدار وثائق الوكيل | milestone | 0d | 2015-12-23 A | 2015-12-23 A | 22 | 100% | 2015-12-23 | 2015-12-23 | 0d |  |  |  |  |  |
| 24 | 4 | **إعداد التقرير السنوي** |  | 22d? | 2015-12-24 | 2016-01-18 |  |  | 2015-12-24 | 2016-01-18 | 22d? | 5.5d |  |  | 216h |  |
| 25 | 4.1 | **إعداد عناصر بلورة موضوع التقرير** |  | 7d? | 2015-12-24 | 2015-12-31 |  |  | 2015-12-24 | 2015-12-31 | 7d? | 16.5d |  |  | 56h |  |
| 26 | 4.1.1 | جدولة وعقد جلسات عمل لتطوير موضوع التقرير |  | 1d? | 2015-12-24 | 2015-12-24 | 23 |  | 2015-12-24 | 2015-12-24 | 1d? | 16.5d | 0d | إدارة العلاقات العامة/علاقات المستثمرين | 8h |  |
| 27 | 4.1.2 | تجميع إحصائيات موضوع التقرير/التحقق من صحة رسائل موضوع التقرير |  | 1d? | 2015-12-26 | 2015-12-26 | 26 |  | 2015-12-26 | 2015-12-26 | 1d? | 16.5d | 0d | إدارة العلاقات العامة/علاقات المستثمرين | 8h |  |
| 28 | 4.1.3 | مقابلة مالكي الفكرة الرئيسية |  | 1d? | 2015-12-27 | 2015-12-27 | 27 |  | 2015-12-27 | 2015-12-27 | 1d? | 16.5d | 0d | إدارة العلاقات العامة/علاقات المستثمرين | 8h |  |
| 29 | 4.1.4 | تطوير التقييمات الأولية لمقطع موضوع التقرير |  | 1d? | 2015-12-28 | 2015-12-28 | 28 |  | 2015-12-28 | 2015-12-28 | 1d? | 16.5d | 0d | إدارة العلاقات العامة/علاقات المستثمرين | 8h |  |
| 30 | 4.1.5 | جدولة جلسات عمل صور وتصميم موقع ويب للفكرة الرئيسية |  | 1d? | 2015-12-29 | 2015-12-29 | 29 |  | 2015-12-29 | 2015-12-29 | 1d? | 16.5d | 0d | إدارة العلاقات العامة/علاقات المستثمرين | 8h |  |
| 31 | 4.1.6 | التحقق من صحة حقائق موضوع التقرير |  | 1d? | 2015-12-30 | 2015-12-30 | 30 |  | 2015-12-30 | 2015-12-30 | 1d? | 16.5d | 0d | إدارة العلاقات العامة/علاقات المستثمرين | 8h |  |
| 32 | 4.1.7 | إنهاء تصميم موضوع التقرير والتقييمات بمشاركة القيادة التنفيذية |  | 1d? | 2015-12-31 | 2015-12-31 | 31 |  | 2015-12-31 | 2015-12-31 | 1d? | 16.5d | 0d | إدارة العلاقات العامة/علاقات المستثمرين | 8h |  |
| 33 | 4.1.8 | اكتمال إصدار موضوع التقرير | milestone | 0d | 2015-12-31 | 2015-12-31 | 32 |  | 2015-12-31 | 2015-12-31 | 0d | 16.5d | 0d |  |  |  |

Notes:
- 4: بمجرد تحديد موضوع التقرير، قم بإعداد قائمة بأسماء المالكين لتضمينها في محتوى الموضوع

| ID | WBS | Task | Type | Duration | Start | Finish | Predecessors | Baseline start | Baseline finish | Baseline duration | Total slack | Free slack | Resources | Work |
| --- | --- | --- | --- | --- | --- | --- | --- | --- | --- | --- | --- | --- | --- | --- |
| 34 | 4.2 | **إعداد خطاب للمساهمين** |  | 15d? | 2016-01-02 | 2016-01-18 |  | 2016-01-02 | 2016-01-18 | 15d? | 5.5d |  |  | 40h |
| 35 | 4.2.1 | ترتيب عقد مقابلة مع رئيس مجلس الإدارة/المدير التنفيذي |  | 1d? | 2016-01-02 | 2016-01-02 | 33 | 2016-01-02 | 2016-01-02 | 1d? | 16.5d | 0d | إدارة العلاقات العامة/علاقات المستثمرين | 8h |
| 36 | 4.2.2 | عقد المقابلة |  | 1d? | 2016-01-03 | 2016-01-03 | 35 | 2016-01-03 | 2016-01-03 | 1d? | 16.5d | 0d | إدارة العلاقات العامة/علاقات المستثمرين; رئيس مجلس الإدارة | 16h |
| 37 | 4.2.3 | إنشاء الخطاب ومراجعته |  | 1d? | 2016-01-04 | 2016-01-04 | 36 | 2016-01-04 | 2016-01-04 | 1d? | 16.5d | 11d | إدارة العلاقات العامة/علاقات المستثمرين | 8h |
| 38 | 4.2.4 | مراجعة الخطاب في ظل النتائج المالية التي تم مراجعتها حسابياً |  | 1d? | 2016-01-18 | 2016-01-18 | 37, 83 | 2016-01-18 | 2016-01-18 | 1d? | 5.5d | 0d | إدارة العلاقات العامة/علاقات المستثمرين | 8h |
| 39 | 4.2.5 | اكتمال الخطاب الموجه إلى المساهمين | milestone | 0d | 2016-01-18 | 2016-01-18 | 38 | 2016-01-18 | 2016-01-18 | 0d | 5.5d |  |  |  |
| 40 | 4.3 | **تحديد العناصر المتعلقة بالعلاقات العام وعلاقات المستثمرين** |  | 10.5d? | 2016-01-06 | 2016-01-18 |  | 2016-01-06 | 2016-01-18 | 10.5d? | 0d |  |  | 120h |
| 41 | 4.3.1 | **تحديد الأحداث الرئيسية لكل من العلاقات العامة وعلاقات المستثمرين** |  | 0.5d? | 2016-01-06 | 2016-01-06 |  | 2016-01-06 | 2016-01-06 | 0.5d? | 0d |  |  | 4h |
| 42 | 4.3.1.1 | تحديد الأحداث الرئيسية لكل من العلاقات العامة وعلاقات المستثمرين (التوافق مع مواعيد التسليم) |  | 0.5d? | 2016-01-06 | 2016-01-06 | 76 | 2016-01-06 | 2016-01-06 | 0.5d? | 0d |  | إدارة العلاقات العامة/علاقات المستثمرين | 4h |
| 43 | 4.3.2 | **إعداد رسائل للعلاقات العامة** |  | 3.5d? | 2016-01-06 | 2016-01-10 |  | 2016-01-06 | 2016-01-10 | 3.5d? | 11d |  |  | 28h |
| 44 | 4.3.2.1 | تحديد رسائل العلاقات العامة لتضمينها في التقرير السنوي |  | 0.5d? | 2016-01-06 | 2016-01-06 | 42 | 2016-01-06 | 2016-01-06 | 0.5d? | 11d | 0d | إدارة العلاقات العامة/علاقات المستثمرين | 4h |
| 45 | 4.3.2.2 | تحديد رسائل العلاقات العامة المتعلقة بالنتائج المالية |  | 2d? | 2016-01-07 | 2016-01-09 | 44 | 2016-01-07 | 2016-01-09 | 2d? | 11d | 0d | إدارة العلاقات العامة/علاقات المستثمرين | 16h |
| 46 | 4.3.2.3 | تنقية قنوات التوزيع والخط الزمني |  | 1d? | 2016-01-10 | 2016-01-10 | 45 | 2016-01-10 | 2016-01-10 | 1d? | 11d | 6d | إدارة العلاقات العامة/علاقات المستثمرين | 8h |
| 47 | 4.3.3 | **تطوير رسائل علاقات المستثمرين** |  | 10d? | 2016-01-06 | 2016-01-18 |  | 2016-01-06 | 2016-01-18 | 10d? | 0d |  |  | 88h |
| 48 | 4.3.3.1 | تحديد رسائل علاقات المستثمرين للتقرير السنوي |  | 2d? | 2016-01-06 | 2016-01-09 | 42 | 2016-01-06 | 2016-01-09 | 2d? | 9.5d | 0d | إدارة العلاقات العامة/علاقات المستثمرين | 16h |
| 49 | 4.3.3.2 | تحديد رسائل علاقات المستخدمين المتعلقة بالنتائج المالية |  | 2d? | 2016-01-09 | 2016-01-11 | 48 | 2016-01-09 | 2016-01-11 | 2d? | 9.5d | 0d | إدارة العلاقات العامة/علاقات المستثمرين | 16h |
| 50 | 4.3.3.3 | تأكيد قوائم وقنوات التوزيع الخاصة بإصدار التقرير السنوي |  | 2d? | 2016-01-11 | 2016-01-13 | 49 | 2016-01-11 | 2016-01-13 | 2d? | 9.5d | 3.5d | إدارة العلاقات العامة/علاقات المستثمرين | 16h |
| 51 | 4.3.3.4 | الحصول على النتائج المالية من رئيس الشئون المالية |  | 0.5d? | 2016-01-18 | 2016-01-18 | 50, 83 | 2016-01-18 | 2016-01-18 | 0.5d? | 6d |  | رئيس الشؤون المالية/المراقب; إدارة العلاقات العامة/علاقات المستثمرين | 8h |
| 52 | 4.3.3.5 | **تأكيد عملية توزيع القائمة البريدية على المساهمين وحصولهم عليها** |  | 4d? | 2016-01-06 | 2016-01-11 |  | 2016-01-06 | 2016-01-11 | 4d? | 0d |  |  | 32h |
| 53 | 4.3.3.5.1 | تأكيد عملية/قائمة التوزيع داخل المؤسسة |  | 1d? | 2016-01-06 | 2016-01-07 | 42 | 2016-01-06 | 2016-01-07 | 1d? | 0d |  | إدارة العلاقات العامة/علاقات المستثمرين | 8h |
| 54 | 4.3.3.5.2 | تأكيد عملية/قائمة توزيع السمسرة |  | 1d? | 2016-01-07 | 2016-01-09 | 53 | 2016-01-07 | 2016-01-09 | 1d? | 0d |  | إدارة العلاقات العامة/علاقات المستثمرين | 8h |
| 55 | 4.3.3.5.3 | تأكيد عملية/قائمة توزيع استثمار الأفراد |  | 1d? | 2016-01-09 | 2016-01-10 | 54 | 2016-01-09 | 2016-01-10 | 1d? | 0d |  | إدارة العلاقات العامة/علاقات المستثمرين | 8h |
| 56 | 4.3.3.5.4 | تأكيد عمليات تحديث/تنسيق/نشر موقع ويب للشركة |  | 1d? | 2016-01-10 | 2016-01-11 | 55 | 2016-01-10 | 2016-01-11 | 1d? | 0d |  | إدارة العلاقات العامة/علاقات المستثمرين | 8h |
| 57 | 4.3.3.5.5 | اكتمال تأكيد عمليتي النشر والتوزيع | milestone | 0d | 2016-01-11 | 2016-01-11 | 56 | 2016-01-11 | 2016-01-11 | 0d | 0d |  |  |  |
| 58 | 4.3.4 | اكتمال عملية التطوير والتخطيط للرسائل الخاصة بالعلاقات العامة وعلاقات المستثمرين | milestone | 0d | 2016-01-11 | 2016-01-11 | 57 | 2016-01-11 | 2016-01-11 | 0d | 0d |  |  |  |

| ID | WBS | Task | Type | Duration | Start | Finish | Predecessors | Baseline start | Baseline finish | Baseline duration | Total slack | Free slack | Resources | Work |
| --- | --- | --- | --- | --- | --- | --- | --- | --- | --- | --- | --- | --- | --- | --- |
| 59 | 5 | **إجراء أنشطة الإقفال المالي** |  | 22.5d? | 2015-12-24 | 2016-01-19 |  | 2015-12-24 | 2016-01-19 | 22.5d? | 0d |  |  | 196h |
| 60 | 5.1 | **تحديد عناصر المراجعة المالية وجدولة مستندات لجنة مراقبة عمليات البورصة (SEC) ذات الصلة** |  | 5d? | 2015-12-24 | 2015-12-29 |  | 2015-12-24 | 2015-12-29 | 5d? | 0d |  |  | 48h |
| 61 | 5.1.1 | وضع جدول للإقفال المالي |  | 1d? | 2015-12-24 | 2015-12-24 | 23 | 2015-12-24 | 2015-12-24 | 1d? | 0d |  | رئيس الشؤون المالية/المراقب | 8h |
| 62 | 5.1.2 | وضع جدول للمراجعة على مراجعة الحسابات الخارجية وتأكيده |  | 1d? | 2015-12-26 | 2015-12-26 | 61 | 2015-12-26 | 2015-12-26 | 1d? | 0d |  | المراجعون الخارجيون; رئيس الشؤون المالية/المراقب | 16h |
| 63 | 5.1.3 | تحديد/تعيين الموارد التي ستقوم بتطوير 'التقارير المالية' والملاحظات وتأكيدها |  | 1d? | 2015-12-27 | 2015-12-27 | 62 | 2015-12-27 | 2015-12-27 | 1d? | 0d |  | رئيس الشؤون المالية/المراقب | 8h |
| 64 | 5.1.4 | تحديد/تعيين الموارد التي ستقوم بتطوير المقطع ‎10-K وتأكيده |  | 1d? | 2015-12-28 | 2015-12-28 | 63 | 2015-12-28 | 2015-12-28 | 1d? | 0d |  | رئيس الشؤون المالية/المراقب | 8h |
| 65 | 5.1.5 | تحديد/تعيين الموارد التي ستقوم بتطوير المقطع 'تقرير الوكيل' وتأكيده |  | 1d? | 2015-12-29 | 2015-12-29 | 64 | 2015-12-29 | 2015-12-29 | 1d? | 0d |  | رئيس الشؤون المالية/المراقب | 8h |
| 66 | 5.1.6 | اكتمال المراجعة المالية وجدولة مستندات 'لجنة مراقبة عمليات البورصة' (SEC) ذات الصلة | milestone | 0d | 2015-12-29 | 2015-12-29 | 65 | 2015-12-29 | 2015-12-29 | 0d | 0d |  |  |  |
| 67 | 5.2 | **تنفيذ الإقفال المالي** |  | 3d? | 2015-12-30 | 2016-01-02 |  | 2015-12-30 | 2016-01-02 | 3d? | 0d |  |  | 24h |
| 68 | 5.2.1 | تسوية حسابات السنة المالية |  | 1d? | 2015-12-30 | 2015-12-30 | 66 | 2015-12-30 | 2015-12-30 | 1d? | 0d |  | رئيس الشؤون المالية/المراقب | 8h |
| 69 | 5.2.2 | مراجعة التعديلات المالية والموافقة عليها (حسابات التسوية والاحتياطي) |  | 1d? | 2015-12-31 | 2015-12-31 | 68 | 2015-12-31 | 2015-12-31 | 1d? | 0d |  | رئيس الشؤون المالية/المراقب | 8h |
| 70 | 5.2.3 | إعداد النتائج المالية ليتم تضمينها في التقرير السنوي والمقطع ‎10-K و'تقرير الوكيل' |  | 1d? | 2016-01-02 | 2016-01-02 | 69 | 2016-01-02 | 2016-01-02 | 1d? | 0d |  | رئيس الشؤون المالية/المراقب | 8h |
| 71 | 5.2.4 | اكتمال الإقفال والنتائج المالية | milestone | 0d | 2016-01-02 | 2016-01-02 | 70 | 2016-01-02 | 2016-01-02 | 0d | 0d |  |  |  |
| 72 | 5.3 | **إصدار ملاحظات حول 'التقارير المالية' ومستندات 'لجنة مراقبة عمليات البورصة' (SEC)** |  | 3d? | 2016-01-03 | 2016-01-05 |  | 2016-01-03 | 2016-01-05 | 3d? | 0d |  |  | 24h |
| 73 | 5.3.1 | كتابة مسودات لملاحظات حول 'التقارير المالية' |  | 1d? | 2016-01-03 | 2016-01-03 | 71 | 2016-01-03 | 2016-01-03 | 1d? | 0d |  | رئيس الشؤون المالية/المراقب | 8h |
| 74 | 5.3.2 | كتابة مسودة للمقطع ‎10-K |  | 1d? | 2016-01-04 | 2016-01-04 | 73 | 2016-01-04 | 2016-01-04 | 1d? | 0d |  | رئيس الشؤون المالية/المراقب | 8h |
| 75 | 5.3.3 | كتابة مسودة لمعلومات 'تقرير الوكيل' |  | 1d? | 2016-01-05 | 2016-01-05 | 74 | 2016-01-05 | 2016-01-05 | 1d? | 0d |  | إدارة الشؤون القانونية | 8h |
| 76 | 5.3.4 | اكتمال إصدار ملاحظات التقارير المالية ومسودات لمستندات 'لجنة مراقبة عمليات البورصة' (SEC) | milestone | 0d | 2016-01-05 | 2016-01-05 | 75 | 2016-01-05 | 2016-01-05 | 0d | 0d |  |  |  |
| 77 | 5.4 | **تنفيذ مراجعة حسابات خارجية** |  | 4d? | 2016-01-13 | 2016-01-17 |  | 2016-01-13 | 2016-01-17 | 4d? | 5d |  |  | 44h |
| 78 | 5.4.1 | إجراء عمليات مراجعة للأموال الخارجية وللفروع |  | 1d? | 2016-01-13 | 2016-01-13 | 91 | 2016-01-13 | 2016-01-13 | 1d? | 5d | 0d | المراجعون الخارجيون | 8h |
| 79 | 5.4.2 | إدارة عملية مراجعة حسابات مالية للشركة |  | 1d? | 2016-01-14 | 2016-01-14 | 78 | 2016-01-14 | 2016-01-14 | 1d? | 5d | 0d | المراجعون الخارجيون | 8h |
| 80 | 5.4.3 | اكتمال مراجعة الحسابات الخارجية | milestone | 0d | 2016-01-14 | 2016-01-14 | 79 | 2016-01-14 | 2016-01-14 | 0d | 5d | 0d |  |  |
| 81 | 5.4.4 | مراجعة نتائج مراجعة الحسابات مع لجنة مراجعة الحسابات وإنهاؤها |  | 1d? | 2016-01-16 | 2016-01-16 | 80 | 2016-01-16 | 2016-01-16 | 1d? | 5d | 0d | لجنة مراجعة الحسابات; المراجعون الخارجيون; رئيس الشؤون المالية/المراقب | 12h |
| 82 | 5.4.5 | اعتماد التقارير المالية/الحصول على شهادات الإدارة العليا |  | 1d? | 2016-01-17 | 2016-01-17 | 81 | 2016-01-17 | 2016-01-17 | 1d? | 5d | 0d | لجنة مراجعة الحسابات; رئيس الشؤون المالية/المراقب | 16h |
| 83 | 5.4.6 | اكتمال مراجعة الحسابات الخارجية | milestone | 0d | 2016-01-17 | 2016-01-17 | 82 | 2016-01-17 | 2016-01-17 | 0d | 5d | 0d |  |  |

Notes:
- 61: وضع أساس الجدول استنادًا إلى الوقت وجهد الموارد اللازمين لتحقيق الأحداث الرئيسية لإقفال الحسابات المالية، وإصدار معلومات التقارير المالية اللازمة للتقرير السنوي و10-K. / بمعنى آخر، تحديد التواريخ أولاً، ثم العمل لتحديد موعد وجوب بدء الأنشطة اللازمة للالتزام بالتواريخ النهائية تلك.
- 77: يتم إجراء أنشطة المراجعة المحاسبية الخارجية على مدار العام. تركز هذه الأنشطة على إقفال نهاية السنة وإصدار التقرير السنوي والتقارير المالية التي سيتم اعتمادها من قبل المراجعين الخارجيين.

| ID | WBS | Task | Type | Duration | Start | Finish | Predecessors | Baseline start | Baseline finish | Baseline duration | Total slack | Free slack | Resources | Work |
| --- | --- | --- | --- | --- | --- | --- | --- | --- | --- | --- | --- | --- | --- | --- |
| 84 | 5.5 | **إجراء مراجعة قانونية داخلية** |  | 6d? | 2016-01-06 | 2016-01-12 |  | 2016-01-06 | 2016-01-12 | 6d? | 5d |  |  | 48h |
| 85 | 5.5.1 | تنسيق الأحداث الرئيسية ومراجعتها بغرض إرفاقها في التقرير السنوي |  | 1d? | 2016-01-06 | 2016-01-06 | 76 | 2016-01-06 | 2016-01-06 | 1d? | 5d | 0d | إدارة الشؤون القانونية | 8h |
| 86 | 5.5.2 | تنسيق الأحداث الرئيسية ومراجعتها بغرض إرفاقها في ‎10-K |  | 1d? | 2016-01-07 | 2016-01-07 | 85 | 2016-01-07 | 2016-01-07 | 1d? | 5d | 0d | إدارة الشؤون القانونية | 8h |
| 87 | 5.5.3 | تنسيق/تطوير عملية إعداد تقرير الوكيل |  | 1d? | 2016-01-09 | 2016-01-09 | 86 | 2016-01-09 | 2016-01-09 | 1d? | 5d | 0d | إدارة الشؤون القانونية | 8h |
| 88 | 5.5.4 | تنسيق/مراجعة الرسالة الموجهة للمساهمين |  | 1d? | 2016-01-10 | 2016-01-10 | 87 | 2016-01-10 | 2016-01-10 | 1d? | 5d | 0d | إدارة الشؤون القانونية | 8h |
| 89 | 5.5.5 | تنسيق/إعادة مراجعة المراجعة التي تمت على عملية 'مراجعة الحسابات الخارجية' والملاحظات عليها |  | 1d? | 2016-01-11 | 2016-01-11 | 88 | 2016-01-11 | 2016-01-11 | 1d? | 5d | 0d | إدارة الشؤون القانونية | 8h |
| 90 | 5.5.6 | تنسيق/مراجعة شهادات الإدارة العليا |  | 1d? | 2016-01-12 | 2016-01-12 | 89 | 2016-01-12 | 2016-01-12 | 1d? | 5d | 0d | إدارة الشؤون القانونية | 8h |
| 91 | 5.5.7 | اكتمال عملية المراجعة القانونية الداخلية | milestone | 0d | 2016-01-12 | 2016-01-12 | 90 | 2016-01-12 | 2016-01-12 | 0d | 5d | 0d |  |  |
| 92 | 5.6 | إعلان النتائج المالية |  | 0.5d? | 2016-01-18 | 2016-01-18 | 46, 83 | 2016-01-18 | 2016-01-18 | 0.5d? | 5d | 0d | لجنة مراجعة الحسابات; رئيس الشؤون المالية/المراقب; إدارة العلاقات العامة/علاقات المستثمرين; رئيس مجلس الإدارة | 8h |
| 93 | 5.7 | اكتمال الإقفال المالي |  | 1d? | 2016-01-18 | 2016-01-19 | 92 | 2016-01-18 | 2016-01-19 | 1d? | 5d |  |  |  |
| 94 | 6 | **إصدار التقرير السنوي** |  | 8d? | 2016-01-11 | 2016-01-20 |  | 2016-01-11 | 2016-01-20 | 8d? | 0d |  |  | 64h |
| 95 | 6.1 | إعداد مسودة لتخطيط تصميم التقرير السنوي وتحديد العناصر النائبة |  | 1d? | 2016-01-11 | 2016-01-12 | 58 | 2016-01-11 | 2016-01-12 | 1d? | 0d |  | إدارة العلاقات العامة/علاقات المستثمرين | 8h |
| 96 | 6.2 | تحضير نماذج تقليدية للإدارة التنفيذية |  | 1d? | 2016-01-12 | 2016-01-13 | 95 | 2016-01-12 | 2016-01-13 | 1d? | 0d |  | إدارة العلاقات العامة/علاقات المستثمرين | 8h |
| 97 | 6.3 | تكرار التصميم/إنهاء جدول الإصدار |  | 1d? | 2016-01-13 | 2016-01-14 | 96 | 2016-01-13 | 2016-01-14 | 1d? | 0d |  | إدارة العلاقات العامة/علاقات المستثمرين | 8h |
| 98 | 6.4 | إنهاء تصميم التقرير السنوي والبيانات النائبة |  | 1d? | 2016-01-14 | 2016-01-16 | 97 | 2016-01-14 | 2016-01-16 | 1d? | 0d |  | إدارة العلاقات العامة/علاقات المستثمرين | 8h |
| 99 | 6.5 | إعداد التخطيط النهائي/الحصول على الموافقة النهائية |  | 1d? | 2016-01-16 | 2016-01-17 | 98 | 2016-01-16 | 2016-01-17 | 1d? | 0d |  | إدارة العلاقات العامة/علاقات المستثمرين | 8h |
| 100 | 6.6 | طباعة التقرير السنوي |  | 1d? | 2016-01-17 | 2016-01-18 | 99 | 2016-01-17 | 2016-01-18 | 1d? | 0d |  | إدارة العلاقات العامة/علاقات المستثمرين | 8h |
| 101 | 6.7 | الحصول على ملف مستند ‎10-K |  | 1d? | 2016-01-18 | 2016-01-19 | 100 | 2016-01-18 | 2016-01-19 | 1d? | 0d |  | إدارة العلاقات العامة/علاقات المستثمرين | 8h |
| 102 | 6.8 | الحصول على ملف مستند تقرير الوكيل |  | 1d? | 2016-01-19 | 2016-01-20 | 101 | 2016-01-19 | 2016-01-20 | 1d? | 0d |  | إدارة العلاقات العامة/علاقات المستثمرين | 8h |
| 103 | 6.9 | اكتمال إصدار التقرير السنوي | milestone | 0d | 2016-01-20 | 2016-01-20 | 102 | 2016-01-20 | 2016-01-20 | 0d | 0d |  |  |  |
| 104 | 7 | **توزيع التقرير السنوي** |  | 4d? | 2016-01-20 | 2016-01-25 |  | 2016-01-20 | 2016-01-25 | 4d? | 0d |  |  | 32h |
| 105 | 7.1 | الحصول على قوائم التوزيع البريدية النهائية |  | 1d? | 2016-01-20 | 2016-01-21 | 103 | 2016-01-20 | 2016-01-21 | 1d? | 0d |  | إدارة العلاقات العامة/علاقات المستثمرين | 8h |
| 106 | 7.2 | طباعة مستندات ‎10-K لمراسلات التقرير السنوي |  | 1d? | 2016-01-21 | 2016-01-23 | 105 | 2016-01-21 | 2016-01-23 | 1d? | 0d |  | إدارة العلاقات العامة/علاقات المستثمرين | 8h |
| 107 | 7.3 | طباعة تقارير الوكيل لمراسلات التقرير السنوي |  | 1d? | 2016-01-23 | 2016-01-24 | 106 | 2016-01-23 | 2016-01-24 | 1d? | 0d |  | إدارة العلاقات العامة/علاقات المستثمرين | 8h |
| 108 | 7.4 | تجميع التقارير السنوية وإرسالها |  | 1d? | 2016-01-24 | 2016-01-25 | 107 | 2016-01-24 | 2016-01-25 | 1d? | 0d |  | إدارة العلاقات العامة/علاقات المستثمرين | 8h |
| 109 | 7.5 | اكتمال التوزيع | milestone | 0d | 2016-01-25 | 2016-01-25 | 108 | 2016-01-25 | 2016-01-25 | 0d | 0d |  |  |  |
| 110 | 8 | اكتمال التقرير السنوي | milestone | 0d | 2016-01-25 | 2016-01-25 | 109 | 2016-01-25 | 2016-01-25 | 0d | 0d |  |  |  |
