# التخطيط لحملة تسويقية

Schedule from MS Project, 2015-12-07 to 2016-08-01, costs in ر.س.‏.
تتميز الحملات الناجحة بالبحث والتفكير الدقيق والتركيز على التفاصيل والتنفيذ. تبدأ عملية التخطيط لحملة تسويقية بفهم لموقعك في السوق وينتهي بجمع البيانات وتحليل مدى فعالية الحملة. يحدد هذا القالب الاعتبارات المتعددة التي قد تحتاجها للتخطيط لحملة تسويقية في شركتك.

## Calendars

- قياسي: Mon-Thu 08:00-12:00, 13:00-17:00; Fri off; Sat-Sun 08:00-12:00, 13:00-17:00.

## Resources

| Resource |
| --- |
| مدير التجهيز |
| مدير التسويق |
| الشركة الراعية |
| قسم المبيعات |
| المبدع |
| مستشار المحتوى |
| التسويق |
| أبحاث التسويق |
| الشراكة الراعية للشركة |
| الخبير التجاري |
| المبيعات الداخلية |
| فريق التسويق |
| تسويق المنتج |
| المدير العام الإقليمي |
| المدير الدولي |
| مدير التعاون الاستراتيجي |
| مندوب التسويق |
| أبحاث التسويق |
| العلاقات العامة الداخلية |
| شركة العلاقات العامة |
| المورّد |

## Schedule

| ID | WBS | Task | Type | Duration | Start | Finish | Predecessors | Total slack | Free slack | Resources | Work |
| --- | --- | --- | --- | --- | --- | --- | --- | --- | --- | --- | --- |
| 1 | 1 | **مراجعة المنظور الأفقي لاستراتيجية الأعمال** |  | 27d? | 2015-12-07 | 2016-01-06 |  | 0d |  |  | 256h |
| 2 | 1.1 | تحديد الفرص والفجوات للخدمات/المنتجات |  | 5d? | 2015-12-07 | 2015-12-12 |  | 0d |  | مدير التسويق | 40h |
| 3 | 1.2 | اكتمال تحليل مواطن القوة والضعف والفرص والتهديدات |  | 5d? | 2015-12-13 | 2015-12-17 | 2 | 0d |  | مدير التسويق | 40h |
| 4 | 1.3 | مراجعة نموذج الأعمال |  | 1d? | 2015-12-19 | 2015-12-19 | 3 | 0d |  | مدير التسويق | 8h |
| 5 | 1.4 | مراجعة الاستراتيجية التسويقية للشركة |  | 3d? | 2015-12-20 | 2015-12-22 | 4 | 0d |  | مدير التسويق | 24h |
| 6 | 1.5 | مراجعة استراتيجية التسويق المحلية |  | 1d? | 2015-12-23 | 2015-12-23 | 5 | 0d |  | مدير التسويق | 8h |
| 7 | 1.6 | مراجعة استراتيجية التسويق العالمية |  | 1d? | 2015-12-24 | 2015-12-24 | 6 | 0d |  | مندوب التسويق | 8h |
| 8 | 1.7 | مراجعة خطة التسويق الخاصة بموازنة الحملة التسويقية |  | 1d? | 2015-12-26 | 2015-12-26 | 7 | 0d |  | مندوب التسويق | 8h |
| 9 | 1.8 | وضع استراتيجية 'تقدم نحو الأسواق' للشركة |  | 1d? | 2015-12-27 | 2015-12-27 | 8 | 0d |  | مدير التسويق | 8h |
| 10 | 1.9 | تقييم مدى التوافق مع الأهداف الاستراتيجية للشركة |  | 2d? | 2015-12-28 | 2015-12-29 | 9 | 0d |  | مدير التسويق; الشركة الراعية | 32h |
| 11 | 1.10 | تقييم المزايا التنافسية |  | 3d? | 2015-12-30 | 2016-01-02 | 10 | 0d |  | مدير التسويق; أبحاث التسويق | 48h |
| 12 | 1.11 | مراجعة الأمور المتعلقة بالمنتجات والخدمات |  | 3d? | 2016-01-03 | 2016-01-05 | 11 | 0d |  | مدير التسويق | 24h |
| 13 | 1.12 | مراجعة أداء الحملة التسويقية السابقة |  | 1d? | 2016-01-06 | 2016-01-06 | 12 | 0d |  | مدير التسويق | 8h |
| 14 | 1.13 | اكتمال مراجعة المنظور الأفقي لاستراتيجية الأعمال | milestone | 0d | 2016-01-06 | 2016-01-06 | 13 | 0d |  |  |  |
| 15 | 2 | **إعداد أفكار للحملة التسويقية** |  | 49d? | 2016-01-07 | 2016-03-03 |  | 0d |  |  | 504h |
| 16 | 2.1 | إنشاء عملية تهدف إلى تأهيل الأفكار |  | 5d? | 2016-01-07 | 2016-01-12 | 14 | 0d |  | فريق التسويق | 40h |
| 17 | 2.2 | وضع عملية لمشاركة الأفكار |  | 5d? | 2016-01-13 | 2016-01-18 | 16 | 0d |  | فريق التسويق | 40h |
| 18 | 2.3 | تجميع الأفكار |  | 1d? | 2016-01-19 | 2016-01-19 | 17 | 0d |  |  |  |
| 19 | 2.4 | صياغة الأفكار وتطويرها بشكل نهائي |  | 5d? | 2016-01-20 | 2016-01-25 | 18 | 0d |  | مدير التسويق | 40h |
| 20 | 2.5 | إجراء أبحاث حول السوق |  | 5d? | 2016-01-26 | 2016-01-31 | 19 | 0d |  | أبحاث التسويق | 40h |
| 21 | 2.6 | تطوير المفاهيم الأولية للحملة |  | 5d? | 2016-02-01 | 2016-02-06 | 20 | 0d |  | مدير التسويق | 40h |
| 22 | 2.7 | تحديد أهداف الحملة |  | 2d? | 2016-02-07 | 2016-02-08 | 21 | 0d |  | مدير التسويق | 16h |
| 23 | 2.8 | تطوير معايير نجاح الحملة |  | 2d? | 2016-02-09 | 2016-02-10 | 22 | 0d |  | مندوب التسويق | 16h |
| 24 | 2.9 | تطوير عملية تتبع الحملة التسويقية وتحليلها |  | 3d? | 2016-02-11 | 2016-02-14 | 23 | 0d |  | فريق التسويق | 24h |
| 25 | 2.10 | التحقق من صحة المفاهيم عن طريق مجموعات الاختبار والأبحاث حول السوق |  | 5d? | 2016-02-15 | 2016-02-20 | 24 | 0d |  | مندوب التسويق | 40h |
| 26 | 2.11 | وضع قائمة أهداف الحملة الرئيسية |  | 1d? | 2016-02-21 | 2016-02-21 | 25 | 0d |  | مندوب التسويق | 8h |
| 27 | 2.12 | تحديد فئات الحملة |  | 1d? | 2016-02-22 | 2016-02-22 | 26 | 5d | 0d | مندوب التسويق | 8h |
| 28 | 2.13 | وضع استراتيجية للعلاقات العامة |  | 3d? | 2016-02-23 | 2016-02-25 | 27 | 5d | 0d | العلاقات العامة الداخلية | 24h |
| 29 | 2.14 | تحديد التوقيت الأمثل المبدئي للترويج للحملة |  | 1d? | 2016-02-27 | 2016-02-27 | 28 | 5d |  | مندوب التسويق | 8h |
| 30 | 2.15 | تحديد حملات التسويق الإقليمية للشركة |  | 5d? | 2016-02-22 | 2016-02-27 | 26 | 0d |  | مدير التسويق | 40h |
| 31 | 2.16 | تحديد حملات التسويق العالمية للشركة |  | 5d? | 2016-02-22 | 2016-02-27 | 26 | 0d |  | مدير التسويق | 40h |
| 32 | 2.17 | تحديد حملات التسويق الدولية للشركة |  | 5d? | 2016-02-22 | 2016-02-27 | 26 | 0d |  | مدير التسويق | 40h |
| 33 | 2.18 | تحديد متطلبات التعريب |  | 5d? | 2016-02-28 | 2016-03-03 | 30, 31, 32 | 0d |  | فريق التسويق | 40h |
| 34 | 2.19 | اكتمال وضع مفاهيم الحملة | milestone | 0d | 2016-03-03 | 2016-03-03 | 33, 29 | 0d |  |  |  |

Notes:
- 3: SWOT - مواطن القوة والضعف والفرص والتهديدات

| ID | WBS | Task | Type | Duration | Start | Finish | Predecessors | Total slack | Free slack | Resources | Work |
| --- | --- | --- | --- | --- | --- | --- | --- | --- | --- | --- | --- |
| 35 | 3 | **وضع استراتيجية لعملية التعريب** |  | 18d? | 2016-03-05 | 2016-03-24 |  | 0d |  |  | 224h |
| 36 | 3.1 | مراجعة أهداف مبيعات الشركة |  | 1d? | 2016-03-05 | 2016-03-05 | 34 | 0d |  | فريق التسويق | 8h |
| 37 | 3.2 | مراجعة نماذج الأعمال الإقليمية |  | 1d? | 2016-03-05 | 2016-03-05 | 34 | 0d |  | مندوب التسويق | 8h |
| 38 | 3.3 | مراجعة نماذج الأعمال العالمية/الدولية |  | 1d? | 2016-03-05 | 2016-03-05 | 34 | 0d |  | مندوب التسويق | 8h |
| 39 | 3.4 | مراجعة أهداف التسويق |  | 1d? | 2016-03-05 | 2016-03-05 | 34 | 0d |  | مندوب التسويق | 8h |
| 40 | 3.5 | مراجعة خطة التسويق |  | 1d? | 2016-03-05 | 2016-03-05 | 34 | 0d |  | مندوب التسويق | 8h |
| 41 | 3.6 | تحديد الفرص المتوفرة للحملة |  | 3d? | 2016-03-06 | 2016-03-08 | 36, 37, 38, 39, 40 | 0d |  | مندوب التسويق | 24h |
| 42 | 3.7 | مراجعة الخدمات وتوافق المنتج والتنبؤ بنجاحه |  | 3d? | 2016-03-09 | 2016-03-12 | 41 | 0d |  | مندوب التسويق | 24h |
| 43 | 3.8 | مراجعة دورات طرح المنتج |  | 3d? | 2016-03-13 | 2016-03-15 | 42 | 6d |  | مندوب التسويق | 24h |
| 44 | 3.9 | تحديد توافق الحملة لكل منطقة |  | 3d? | 2016-03-13 | 2016-03-15 | 42 | 0d |  | مدير التسويق | 24h |
| 45 | 3.10 | تحديد معايير نجاح الحملة لكل منطقة |  | 3d? | 2016-03-16 | 2016-03-19 | 44 | 0d |  | مدير التسويق; المدير العام الإقليمي | 48h |
| 46 | 3.11 | تحديد آلية التتبع |  | 3d? | 2016-03-20 | 2016-03-22 | 45 | 0d |  | فريق التسويق | 24h |
| 47 | 3.12 | وضع استراتيجية لعملية التعريب |  | 2d? | 2016-03-23 | 2016-03-24 | 46, 44, 43 | 0d |  | فريق التسويق | 16h |
| 48 | 3.13 | اكتمال استراتيجية التعريب | milestone | 0d | 2016-03-24 | 2016-03-24 | 47 | 0d |  |  |  |
| 49 | 4 | **التواصل مع المؤسسة الداخلية وتدريبها** |  | 24d? | 2016-03-26 | 2016-04-21 |  | 0d |  |  | 240h |
| 50 | 4.1 | تنفيذ عملية للاتصالات الداخلية في الشركة |  | 3d? | 2016-03-26 | 2016-03-28 | 48 | 0d |  | فريق التسويق | 24h |
| 51 | 4.2 | تحديد عملية الاتصالات الإقليمية والمحلية |  | 5d? | 2016-03-29 | 2016-04-03 | 50 | 0d |  | فريق التسويق | 40h |
| 52 | 4.3 | تخطيط أساليب الاتصال والتجهيز والتوقيت |  | 4d? | 2016-04-04 | 2016-04-07 | 51 | 0d |  | مدير التجهيز; فريق التسويق | 64h |
| 53 | 4.4 | الاتصالات الإقليمية والدولية للمبيعات والتسويق والإدارة |  | 5d? | 2016-04-09 | 2016-04-13 | 52 | 0d |  | مندوب التسويق | 40h |
| 54 | 4.5 | تحديد الأنظمة الداخلية للاستجابة للحملة |  | 5d? | 2016-04-14 | 2016-04-19 | 53 | 0d |  | فريق التسويق | 40h |
| 55 | 4.6 | إنشاء خطة اتصالات |  | 2d? | 2016-04-20 | 2016-04-21 | 54 | 0d |  |  |  |
| 56 | 4.7 | تحديد متطلبات التدريب الداخلي |  | 1d? | 2016-03-26 | 2016-03-26 | 48 | 20d | 0d | فريق التسويق | 8h |
| 57 | 4.8 | تطوير التدريب الداخلي |  | 3d? | 2016-03-27 | 2016-03-29 | 56 | 20d |  | فريق التسويق | 24h |
| 58 | 4.9 | اكتمال الاتصالات الداخلية والتدريب للشركة | milestone | 0d | 2016-04-21 | 2016-04-21 | 55, 57 | 0d |  |  |  |

| ID | WBS | Task | Type | Duration | Start | Finish | Predecessors | Total slack | Free slack | Resources | Work |
| --- | --- | --- | --- | --- | --- | --- | --- | --- | --- | --- | --- |
| 59 | 5 | **إدارة علاقات العملاء** |  | 16d? | 2016-03-26 | 2016-04-12 |  | 8d |  |  | 152h |
| 60 | 5.1 | مراجعة بيانات العملاء وملاحظاتهم |  | 3d? | 2016-03-26 | 2016-03-28 | 48 | 8d | 0d | فريق التسويق | 24h |
| 61 | 5.2 | مراجعة قطاعات الشركة وقنواتها |  | 3d? | 2016-03-26 | 2016-03-28 | 48 | 8d | 0d | فريق التسويق | 24h |
| 62 | 5.3 | تحديد الأهداف لكل حملة تسويقية |  | 3d? | 2016-03-29 | 2016-03-31 | 60, 61 | 8d | 0d | أبحاث التسويق | 24h |
| 63 | 5.4 | تقسيم البيانات لكل حملة تسويقية |  | 5d? | 2016-04-02 | 2016-04-06 | 62 | 8d | 0d | فريق التسويق | 40h |
| 64 | 5.5 | تحضير/تدبير قوائم لكل حملة تسويقية |  | 5d? | 2016-04-07 | 2016-04-12 | 63 | 8d | 0d | فريق التسويق | 40h |
| 65 | 5.6 | اكتمال إدارة علاقات العملاء | milestone | 0d | 2016-04-12 | 2016-04-12 | 64 | 8d |  |  |  |
| 66 | 6 | **تحليل نماذج الأعمال الإقليمية/العالمية/الدولية** |  | 9d? | 2016-03-26 | 2016-04-04 |  | 15d |  |  | 88h |
| 67 | 6.1 | تحديد المناطق المستهدفة |  | 1d? | 2016-03-26 | 2016-03-26 | 48 | 15d | 0d | فريق التسويق | 8h |
| 68 | 6.2 | تحديد الفجوات المحلية |  | 2d? | 2016-03-27 | 2016-03-28 | 67 | 15d | 0d | فريق التسويق | 16h |
| 69 | 6.3 | مراجعة المنافسة المحلية |  | 3d? | 2016-03-29 | 2016-03-31 | 68 | 15d | 0d | أبحاث التسويق | 24h |
| 70 | 6.4 | وضع المزايا التنافسية |  | 2d? | 2016-04-02 | 2016-04-03 | 69 | 15d | 0d | مدير التسويق; أبحاث التسويق | 32h |
| 71 | 6.5 | تحديد السعي نحو الشركاء |  | 1d? | 2016-04-04 | 2016-04-04 | 70 | 15d | 0d | مدير التعاون الاستراتيجي | 8h |
| 72 | 6.6 | اكتمال نماذج الأعمال الإقليمية/العالمية/الدولية | milestone | 0d | 2016-04-04 | 2016-04-04 | 71 | 15d |  |  |  |
| 73 | 7 | **تطوير الحملة التسويقية** |  | 14d? | 2016-04-23 | 2016-05-08 |  | 0d |  |  | 104h |
| 74 | 7.1 | مراجعة مفاهيم الحملة |  | 2d? | 2016-04-23 | 2016-04-24 | 58, 65, 72 | 0d |  | مدير التسويق | 16h |
| 75 | 7.2 | وضع قائمة للحملة |  | 1d? | 2016-04-25 | 2016-04-25 | 74 | 0d |  | مندوب التسويق | 8h |
| 76 | 7.3 | تحديد قادة الحملة |  | 1d? | 2016-04-26 | 2016-04-26 | 75 | 0d |  | مندوب التسويق | 8h |
| 77 | 7.4 | تطوير حملات مستقلة |  | 1d? | 2016-04-27 | 2016-04-27 | 76 | 0d |  |  |  |
| 78 | 7.5 | تطوير جداول للحملات |  | 2d? | 2016-04-28 | 2016-04-30 | 77 | 0d |  | مندوب التسويق | 16h |
| 79 | 7.6 | تحديد إجراءات التنفيذ |  | 2d? | 2016-05-01 | 2016-05-02 | 78 | 0d |  | مدير التسويق | 16h |
| 80 | 7.7 | تحديد وسائل الإعلان/الترويج ومدى توافقها |  | 5d? | 2016-05-03 | 2016-05-08 | 79 | 0d |  | مدير التسويق | 40h |
| 81 | 7.8 | اكتمال تطوير الحملة | milestone | 0d | 2016-05-08 | 2016-05-08 | 80 | 0d |  |  |  |
| 82 | 8 | **تعيين مبدع للحملة واختباره** |  | 30d? | 2016-05-09 | 2016-06-12 |  | 0d |  |  | 312h |
| 83 | 8.1 | اختيار مورّد للعمل كمبدع |  | 1d? | 2016-05-09 | 2016-05-09 | 81 | 0d |  | مدير التسويق; مندوب التسويق | 16h |
| 84 | 8.2 | تحديد أسلوب الرسالة/الخطاب الذي تستخدمه الحملة |  | 3d? | 2016-05-10 | 2016-05-12 | 83 | 0d |  | مدير التسويق; المبدع | 48h |
| 85 | 8.3 | تطوير المفاهيم العامة |  | 5d? | 2016-05-14 | 2016-05-18 | 84 | 0d |  | المبدع | 40h |
| 86 | 8.4 | اختيار مبدع للحملة |  | 5d? | 2016-05-19 | 2016-05-24 | 85 | 0d |  | مدير التسويق; الشراكة الراعية للشركة | 80h |
| 87 | 8.5 | إعداد مواد الاختبار الأولي |  | 5d? | 2016-05-25 | 2016-05-30 | 86 | 0d |  | مندوب التسويق | 40h |
| 88 | 8.6 | الاختبار الأولي للحملة |  | 5d? | 2016-05-31 | 2016-06-05 | 87 | 0d |  | مندوب التسويق | 40h |
| 89 | 8.7 | تحديد ما إذا كان المبدع الذي تم اختباره يحقق الأهداف المرجوة أم لا |  | 1d? | 2016-06-06 | 2016-06-06 | 88 | 0d |  | مندوب التسويق | 8h |
| 90 | 8.8 | تطوير المبدع استنادًا إلى نتائج الاختبار الأولي |  | 5d? | 2016-06-07 | 2016-06-12 | 89 | 0d |  | المبدع | 40h |
| 91 | 8.9 | اكتمال عملية تعيين مبدع للحملة واختباره | milestone | 0d | 2016-06-12 | 2016-06-12 | 90 | 0d |  |  |  |

| ID | WBS | Task | Type | Duration | Start | Finish | Predecessors | Total slack | Free slack | Resources | Work | Cost |
| --- | --- | --- | --- | --- | --- | --- | --- | --- | --- | --- | --- | --- |
| 92 | 9 | **وضع استراتيجية لعمليات الدعاية الخارجية** |  | 9d? | 2016-06-13 | 2016-06-22 |  | 0d |  |  | 368h |  |
| 93 | 9.1 | تطوير استراتيجية حملة الدعاية |  | 2d? | 2016-06-13 | 2016-06-14 | 91 | 0d |  | مدير التسويق; العلاقات العامة الداخلية | 32h |  |
| 94 | 9.2 | إعداد نشرات صحفية |  | 4d? | 2016-06-15 | 2016-06-19 | 93 | 0d |  | العلاقات العامة الداخلية; شركة العلاقات العامة | 64h |  |
| 95 | 9.3 | إعداد إعلانات |  | 4d? | 2016-06-15 | 2016-06-19 | 93 | 0d |  | العلاقات العامة الداخلية; شركة العلاقات العامة | 64h |  |
| 96 | 9.4 | توفير معلومات ما قبل الإصدار للمحللين |  | 3d? | 2016-06-20 | 2016-06-22 | 94, 95 | 0d |  | العلاقات العامة الداخلية; شركة العلاقات العامة | 48h |  |
| 97 | 9.5 | إثارة 'ضجة' |  | 5d? | 2016-06-15 | 2016-06-20 | 93 | 2d |  | العلاقات العامة الداخلية; شركة العلاقات العامة | 80h |  |
| 98 | 9.6 | تنفيذ استراتيجية الدعاية |  | 5d? | 2016-06-13 | 2016-06-18 | 91 | 4d |  | العلاقات العامة الداخلية; شركة العلاقات العامة | 80h |  |
| 99 | 9.7 | الترويج - اكتمال الترويج الخارجي | milestone | 0d | 2016-06-22 | 2016-06-22 | 98, 96, 97 | 0d |  |  |  |  |
| 100 | 10 | **الإنتاج** |  | 14d? | 2016-06-23 | 2016-07-09 |  | 0d |  |  | 112h | 25,000 |
| 101 | 10.1 | إرسال موارد الحملة إلى وسائل الإعلام |  | 3d? | 2016-06-23 | 2016-06-26 | 99 | 0d |  | مندوب التسويق | 24h |  |
| 102 | 10.2 | اختيار مورّد لأساليب الإنتاج الملائمة |  | 1d? | 2016-06-27 | 2016-06-27 | 101 | 20d | 0d | فريق التسويق | 8h |  |
| 103 | 10.3 | إنتاج المواد |  | 5d? | 2016-06-28 | 2016-07-03 | 102 | 20d | 0d | المورّد | 40h |  |
| 104 | 10.4 | توزيع المواد |  | 5d? | 2016-07-04 | 2016-07-09 | 103 | 20d | 0d | المورّد | 40h |  |
| 105 | 10.5 | اكتمال الإنتاج | milestone | 0d | 2016-07-09 | 2016-07-09 | 104 | 20d |  |  |  |  |
| 106 | 11 | **إصدار الحملة التسويقية** |  | 13d? | 2016-06-27 | 2016-07-11 |  | 0d |  |  | 144h |  |
| 107 | 11.1 | وضع جداول لإصدار الحملة |  | 2d? | 2016-06-27 | 2016-06-28 | 101 | 0d |  | مندوب التسويق | 16h |  |
| 108 | 11.2 | تحديد فرق عملية الإصدار |  | 1d? | 2016-06-29 | 2016-06-29 | 107 | 0d |  | مدير التسويق | 8h |  |
| 109 | 11.3 | إجراء اتصالات مبيعات داخلية |  | 5d? | 2016-06-30 | 2016-07-05 | 108 | 0d |  | مدير التسويق; المبيعات الداخلية | 80h |  |
| 110 | 11.4 | تنفيذ الحملة |  | 5d? | 2016-07-06 | 2016-07-11 | 109 | 0d |  | مدير التسويق | 40h |  |
| 111 | 11.5 | اكتمال إصدار الحملة | milestone | 0d | 2016-07-11 | 2016-07-11 | 110 | 0d |  |  |  |  |
| 112 | 12 | **تأثير الحملة التسويقية** |  | 18d? | 2016-07-12 | 2016-08-01 |  | 0d |  |  | 192h |  |
| 113 | 12.1 | تقييم تأثير الحملة التسويقية |  | 3d? | 2016-07-12 | 2016-07-14 | 111 | 3d |  | مدير التسويق | 24h |  |
| 114 | 12.2 | مراجعة المبيعات الإقليمية |  | 1d? | 2016-07-12 | 2016-07-12 | 111 | 0d |  | مدير التسويق; قسم المبيعات | 16h |  |
| 115 | 12.3 | مراجعة المبيعات العالمية |  | 1d? | 2016-07-13 | 2016-07-13 | 114 | 0d |  | مدير التسويق; قسم المبيعات | 16h |  |
| 116 | 12.4 | مراجعة بيانات العملاء وملاحظاتهم |  | 1d? | 2016-07-14 | 2016-07-14 | 115 | 0d |  | فريق التسويق; مندوب التسويق | 16h |  |
| 117 | 12.5 | إجراء تحليل للسوق |  | 3d? | 2016-07-16 | 2016-07-18 | 116 | 0d |  | أبحاث التسويق | 24h |  |
| 118 | 12.6 | مراجعة مقاييس النجاح |  | 3d? | 2016-07-19 | 2016-07-21 | 113, 114, 115, 116, 117 | 0d |  | مدير التسويق | 24h |  |
| 119 | 12.7 | قياس تأثير الحملة |  | 3d? | 2016-07-23 | 2016-07-25 | 118 | 0d |  | مدير التسويق | 24h |  |
| 120 | 12.8 | تحديد أية فجوات |  | 1d? | 2016-07-26 | 2016-07-26 | 119 | 0d |  | مدير التسويق | 8h |  |
| 121 | 12.9 | وضع أفكار لحملات تسويقية مستقبلية |  | 5d? | 2016-07-27 | 2016-08-01 | 120 | 0d |  | مدير التسويق | 40h |  |
| 122 | 12.10 | تأثير الحملة التسويقية | milestone | 0d | 2016-08-01 | 2016-08-01 | 121 | 0d |  |  |  |  |
| 123 | 13 | اكتمال التخطيط للحملة التسويقية | milestone | 0d | 2016-08-01 | 2016-08-01 | 122 | 0d |  |  |  |  |

Notes:
- 92: قد يكون هناك جدول علاقات عامة أكثر تفصيلاً لإدارة العمل بالنسبة لهذه المرحلة من تنفيذ الحملة التسويقية.
