# كتاب الذواقة للطبخ

Schedule from MS Project, 2012-07-11 to 2012-10-31, status date 2012-07-11, costs in $, A marks actual dates.
Lucerne Publishing

## Calendars

- Standard: Mon-Fri 08:00-12:00, 13:00-17:00; Sat-Sun off.

## Resources

| Resource | Rate |
| --- | --- |
| ضياء محمود | 62 |
| فاتن عيد | 48 |
| شيماء حمدان | 44 |
| شادية سيف | 55 |
| كامل أنور | 52.5 |
| خدمات الطباعة |  |
| خدمات تجهيز الألوان |  |
| نسخ المحررين |  |

## Schedule

| ID | WBS | Task | Type | Duration | Start | Finish | Predecessors | Complete | Baseline start | Baseline finish | Baseline duration | Total slack | Free slack | Constraint | Resources | Work | Actual work | Cost | Baseline cost | Actual cost |
| --- | --- | --- | --- | --- | --- | --- | --- | --- | --- | --- | --- | --- | --- | --- | --- | --- | --- | --- | --- | --- |
| 1 | 1 | **مرحلة الاقتناع** |  | 31d | 2012-07-11 A | 2012-08-22 A |  | 100% | 2012-07-09 | 2012-08-10 | 25d |  |  |  |  | 232h | 232h | 12,180 | 10,500 | 12,180 |
| 2 | 1.1 | استلام النسخة | milestone | 0d | 2012-07-11 A | 2012-07-11 A |  | 100% | 2012-07-09 | 2012-07-09 | 0d |  |  |  | كامل أنور |  |  |  |  |  |
| 3 | 1.2 | تحترير المحتوى |  | 29d | 2012-07-11 A | 2012-08-22 A | 2 | 100% | 2012-07-09 | 2012-08-10 | 25d |  |  |  | كامل أنور | 232h | 232h | 12,180 | 10,500 | 12,180 |
| 4 | 1.3 | الانتقال الى مرحلة التحرير | milestone | 0d | 2012-08-22 A | 2012-08-22 A | 3 | 100% | 2012-08-10 | 2012-08-10 | 0d |  |  |  | كامل أنور |  |  |  |  |  |
| 5 | 2 | **مرحلة التحرير** |  | 30d | 2012-08-23 | 2012-10-03 | 1 |  | 2012-08-13 | 2012-09-21 | 30d | 0d |  |  |  | 240h |  | 3,520 | 3,520 |  |
| 6 | 2.1 | تنظيم مخطوطة التحرير على النسخة |  | 5d | 2012-08-23 | 2012-08-29 |  |  | 2012-08-13 | 2012-08-17 | 5d | 0d |  |  | شيماء حمدان | 40h |  | 1,760 | 1,760 |  |
| 7 | 2.2 | بدء عملية التحرير |  | 20d | 2012-08-30 | 2012-09-26 | 6 |  | 2012-08-20 | 2012-09-14 | 20d | 0d |  |  | نسخ المحررين | 160h |  |  |  |  |
| 8 | 2.3 | جمع ودمج النسخة الموزعة |  | 5d | 2012-09-27 | 2012-10-03 | 7 |  | 2012-09-17 | 2012-09-21 | 5d | 0d |  | finish no earlier than 2012-10-03 | شيماء حمدان | 40h |  | 1,760 | 1,760 |  |
| 9 | 2.4 | الانتقال الى مرحلة الإنتاج | milestone | 0d | 2012-10-03 | 2012-10-03 | 8 |  | 2012-09-21 | 2012-09-21 | 0d | 0d |  |  | شيماء حمدان |  |  |  |  |  |
| 10 | 3 | **مرحلة التصميم والإنتاج** |  | 29d | 2012-08-23 | 2012-10-02 | 5SS |  | 2012-08-13 | 2012-09-07 | 20d | 1d |  |  |  | 320h |  | 16,160 | 16,160 |  |
| 11 | 3.1 | تصميم الغلاف |  | 5d | 2012-08-23 | 2012-08-29 |  |  | 2012-08-13 | 2012-08-17 | 5d | 12d | 0d |  | شادية سيف | 40h |  | 2,200 | 2,200 |  |
| 12 | 3.2 | إعداد الصفحات |  | 10d | 2012-09-12 | 2012-09-25 | 11 |  | 2012-08-20 | 2012-08-31 | 10d | 1d | 0d | start no earlier than 2012-09-12 | شيماء حمدان; فاتن عيد | 160h |  | 7,360 | 7,360 |  |
| 13 | 3.3 | توضيح التصميم الداخلي |  | 15d | 2012-09-12 | 2012-10-02 | 12SS |  | 2012-08-20 | 2012-09-07 | 15d | 3d |  |  | شادية سيف | 120h |  | 6,600 | 6,600 |  |
| 14 | 4 | **مراجعة الصفحات** |  | 20d | 2012-10-04 | 2012-10-31 | 10, 5 |  | 2012-09-24 | 2012-10-19 | 20d | 0d |  |  |  | 280h |  | 14,580 | 14,580 |  |
| 15 | 4.1 | تجهيز جدول المحتويات والفهارس |  | 10d | 2012-10-04 | 2012-10-17 |  |  | 2012-09-24 | 2012-10-05 | 10d | 0d |  |  | ضياء محمود; فاتن عيد | 160h |  | 8,800 | 8,800 |  |
| 16 | 4.2 | دمج الصفحات الأولى |  | 5d | 2012-10-18 | 2012-10-24 | 15 |  | 2012-10-08 | 2012-10-12 | 5d | 0d |  |  | كامل أنور | 40h |  | 2,100 | 2,100 |  |
| 17 | 4.3 | إرسال الصفحات التي تمت الموافقة عليها للإنتاج | milestone | 0d | 2012-10-24 | 2012-10-24 | 16 |  | 2012-10-12 | 2012-10-12 | 0d | 0d |  |  | شيماء حمدان |  |  |  |  |  |
| 18 | 4.4 | ادخال التصويبات على الصفحات |  | 5d | 2012-10-25 | 2012-10-31 | 17 |  | 2012-10-15 | 2012-10-19 | 5d | 0d |  |  | فاتن عيد; شيماء حمدان | 80h |  | 3,680 | 3,680 |  |
| 19 | 4.5 | الإرسال الى الطباعة | milestone | 0d | 2012-10-31 | 2012-10-31 | 18 |  |  |  |  | 0d |  |  |  |  |  |  |  |  |
